Schedule from MS Project, 2012-02-16 to 2012-05-31, costs in zł.

## Calendars

- Standardowy: Mon-Fri 09:00-13:00, 14:00-18:00; Sat-Sun off.

## Resources

| Resource | Rate |
| --- | --- |
| Kierownik projektu | 100 |
| Kierownik zespołu analityków | 100 |
| Kierownik zespołu projektantów | 100 |
| Kierownik zespołu programistów | 100 |
| Analityk | 80 |
| Projektant | 80 |
| Programista | 100 |
| Tester | 40 |
| Szkoleniowiec | 40 |
| Dokumentalista | 40 |
| Spec. Ds. jakości | 60 |
| Kierownik zespołu kontroli zmian | 100 |
| Pracownik techniczny | 30 |

## Schedule

| ID | WBS | Task | Duration | Start | Finish | Predecessors | Total slack | Free slack | Constraint | Resources | Work | Cost |
| --- | --- | --- | --- | --- | --- | --- | --- | --- | --- | --- | --- | --- |
| 1 | 1 | **Analiza wymagań** | 20d | 2012-02-16 | 2012-03-14 |  |  |  |  | Analityk; Dokumentalista; Kierownik projektu; Pracownik techniczny; Programista; Projektant; Spec. Ds. jakości; Szkoleniowiec; Tester | 1712h | 110,080 |
| 2 | 1.1 | Definicja przedsięwzięcia | 2d | 2012-02-16 | 2012-02-17 |  | 0d |  |  | Analityk; Dokumentalista; Kierownik projektu; Pracownik techniczny | 64h | 4,000 |
| 3 | 1.2 | Określenie wymagań klienta | 3d | 2012-02-20 | 2012-02-22 | 2 | 15d |  |  | Spec. Ds. jakości | 24h | 1,440 |
| 4 | 1.3 | Zbadanie stanu aktualnego | 4d | 2012-02-20 | 2012-02-23 | 2 | 1d | 0d |  | Analityk | 32h | 2,560 |
| 5 | 1.4 | Określenie stanu pożądanego | 4d | 2012-02-24 | 2012-02-29 | 4 | 1d | 0d |  | Analityk | 32h | 2,560 |
| 6 | 1.5 | Określenie funkcjonalności | 4d | 2012-03-01 | 2012-03-06 | 5 | 1d | 0d |  | Analityk | 32h | 2,560 |
| 7 | 1.6 | Określenie zasobów | 2d | 2012-03-07 | 2012-03-08 | 6 | 1d | 0d |  | Analityk; Projektant | 32h | 2,560 |
| 8 | 1.7 | Określenie krytycznych czynników sukcesu | 3d | 2012-03-09 | 2012-03-13 | 7 | 1d | 0d |  | Spec. Ds. jakości; Dokumentalista | 48h | 2,400 |
| 9 | 1.8 | Punkt kontrolny | 1d | 2012-03-14 | 2012-03-14 | 8 | 56d |  | start no earlier than 2012-03-14 | Kierownik projektu | 8h | 800 |
| 10 | 2 | **Planowanie** | 16d | 2012-03-15 | 2012-04-05 | 1 |  |  |  |  | 368h | 27,440 |
| 11 | 2.1 | Budżetowanie kosztów | 5d | 2012-03-15 | 2012-03-21 | 6 | 51d |  | start no earlier than 2012-03-15 | Analityk; Pracownik techniczny; Programista; Projektant | 160h | 11,600 |
| 12 | 2.2 | Opracowanie organizacji zespołu | 3d | 2012-03-15 | 2012-03-19 | 6 | 0d |  | start no earlier than 2012-03-15 | Kierownik projektu | 24h | 2,400 |
| 13 | 2.3 | Stworzenie WBS | 4d | 2012-03-20 | 2012-03-23 | 12 | 0d |  |  | Analityk; Projektant; Spec. Ds. jakości | 96h | 7,040 |
| 14 | 2.4 | Stworzenie sieci działań | 3d | 2012-03-26 | 2012-03-28 | 13 | 0d |  |  | Analityk | 24h | 1,920 |
| 15 | 2.5 | Stworzenie harmonogramu działań | 3d | 2012-03-29 | 2012-04-02 | 14 | 0d |  |  | Analityk | 24h | 1,920 |
| 16 | 2.6 | Przydział zasobów do zadań | 2d | 2012-04-03 | 2012-04-04 | 15 | 0d |  |  | Analityk; Pracownik techniczny | 32h | 1,760 |
| 17 | 2.7 | Punkt kontrolny | 1d | 2012-04-05 | 2012-04-05 | 16 | 0d |  |  | Kierownik projektu | 8h | 800 |
| 18 | 3 | **Realizacja** | 24d | 2012-04-06 | 2012-05-09 | 10 |  |  |  |  | 376h | 25,120 |
| 19 | 3.1 | Tworzenie kodu aplikacji | 15d | 2012-04-06 | 2012-04-26 | 6 | 0d |  | start no earlier than 2012-04-06 | Pracownik techniczny; Programista | 240h | 15,600 |
| 20 | 3.2 | Tworzenie szaty graficznej | 3d | 2012-04-27 | 2012-05-01 | 19 | 0d |  |  | Pracownik techniczny; Programista | 48h | 3,120 |
| 21 | 3.3 | Tworzenie dokumentacji | 5d | 2012-05-02 | 2012-05-08 | 20 | 0d |  |  | Dokumentalista; Programista | 80h | 5,600 |
| 22 | 3.4 | Punkt kontrolny | 1d | 2012-05-09 | 2012-05-09 | 21 | 0d |  |  | Kierownik projektu | 8h | 800 |
| 23 | 4 | **Testowanie** | 6d | 2012-05-10 | 2012-05-17 | 18 |  |  |  |  | 104h | 5,600 |
| 24 | 4.1 | Wstępne testy | 1d | 2012-05-10 | 2012-05-10 | 21 | 0d |  | start no earlier than 2012-05-10 | Tester; Pracownik techniczny | 16h | 560 |
| 25 | 4.2 | Testy funkcjonalności | 1d | 2012-05-11 | 2012-05-11 | 24 | 4d |  |  | Tester; Pracownik techniczny | 16h | 560 |
| 26 | 4.3 | Testy wydajności | 1d | 2012-05-11 | 2012-05-11 | 24 | 0d |  |  | Tester; Pracownik techniczny | 16h | 560 |
| 27 | 4.4 | Weryfikacja wyników z oczekiwaniami | 1d | 2012-05-14 | 2012-05-14 | 26 | 0d |  |  | Dokumentalista; Analityk | 16h | 960 |
| 28 | 4.5 | Poprawianie niezgodności | 1d | 2012-05-15 | 2012-05-15 | 27 | 0d |  |  | Programista | 8h | 800 |
| 29 | 4.6 | Testowanie poprawek | 1d | 2012-05-16 | 2012-05-16 | 28 | 0d |  |  | Programista; Tester; Pracownik techniczny | 24h | 1,360 |
| 30 | 4.7 | Punkt kontrolny | 1d | 2012-05-17 | 2012-05-17 | 29 | 0d |  |  | Kierownik projektu | 8h | 800 |

| ID | WBS | Task | Duration | Start | Finish | Predecessors | Total slack | Constraint | Resources | Work | Cost |
| --- | --- | --- | --- | --- | --- | --- | --- | --- | --- | --- | --- |
| 31 | 5 | **Wdrażanie** | 7d | 2012-05-18 | 2012-05-28 | 23 |  |  |  | 120h | 7,920 |
| 32 | 5.1 | Opracowanie dokumentacji | 2d | 2012-05-18 | 2012-05-21 | 29 | 0d | start no earlier than 2012-05-18 | Dokumentalista; Programista | 32h | 2,240 |
| 33 | 5.2 | Przekazanie dokumentacji | 1d | 2012-05-22 | 2012-05-22 | 32 | 0d |  | Kierownik projektu | 8h | 800 |
| 34 | 5.3 | Wdrażanie systemu | 3d | 2012-05-23 | 2012-05-25 | 33 | 1d |  | Pracownik techniczny; Programista | 48h | 3,120 |
| 35 | 5.4 | Szkolenia pracowników | 3d | 2012-05-23 | 2012-05-25 | 33 | 0d |  | Szkoleniowiec | 24h | 960 |
| 36 | 5.5 | Punkt kontrolny | 1d | 2012-05-28 | 2012-05-28 | 35 | 0d |  | Kierownik projektu | 8h | 800 |
| 37 | 6 | **Eksploatacja** | 3d | 2012-05-29 | 2012-05-31 | 31 |  |  |  | 120h | 8,240 |
| 38 | 6.1 | Kontrola systemu | 1d | 2012-05-29 | 2012-05-29 | 34 | 0d | start no earlier than 2012-05-29 | Programista; Spec. Ds. jakości; Tester; Pracownik techniczny | 32h | 1,840 |
| 39 | 6.2 | Konserwacja | 2d | 2012-05-30 | 2012-05-31 | 38 | 0d |  | Programista | 16h | 1,600 |
| 40 | 6.3 | Pomoc techniczna | 3d | 2012-05-29 | 2012-05-31 | 35 | 0d | start no earlier than 2012-05-29 | Spec. Ds. jakości; Programista; Szkoleniowiec | 72h | 4,800 |
| 41 | 7 | **Nadzór nad projektem** | 74d | 2012-02-20 | 2012-05-31 | 2 |  |  |  | 592h | 59,200 |
| 42 | 7.1 | Kontrola realizacji zaplanowanych zadań | 74d | 2012-02-20 | 2012-05-31 | 2 | 0d | finish no earlier than 2012-05-31 | Kierownik projektu | 592h | 59,200 |
